# 08prop

Schedule from MS Project, 2008-01-01 to 2008-12-26.
MBARI

## Calendars

- Standard: Mon-Fri 08:00-12:00, 13:00-17:00; Sat-Sun off.

## Schedule

| ID | WBS | Task | Type | Duration | Start | Finish | Predecessors | Total slack | Free slack | Constraint |
| --- | --- | --- | --- | --- | --- | --- | --- | --- | --- | --- |
| 1 | 1 | **ASTEP** |  | 239d | 2008-01-01 | 2008-11-28 |  | 20d |  |  |
| 2 | 1.1 | Assemble and Test 4km Deep Sampler |  | 80d | 2008-01-01 | 2008-04-21 |  | 39d | 0d |  |
| 3 | 1.2 | Integrate 4k D-ESP |  | 20d | 2008-04-22 | 2008-05-19 | 2 | 39d | 0d |  |
| 4 | 1.3 | 4km (Pressurized Test) Readiness R | milestone | 0d | 2008-05-19 | 2008-05-19 | 3 | 39d | 0d |  |
| 5 | 1.4 | Simulated 4km Testing |  | 30d | 2008-05-20 | 2008-06-30 | 4 | 39d | 0d |  |
| 6 | 1.5 | Configure 4km D-ESP for profiling |  | 20d | 2008-07-01 | 2008-07-28 | 5 | 39d | 0d |  |
| 7 | 1.6 | 4km D-ESP (Deployment) Readiness review | milestone | 0d | 2008-07-28 | 2008-07-28 | 6 | 39d | 19d |  |
| 8 | 1.7 | 4km D-ESP (Flyer) |  | 5d | 2008-08-25 | 2008-08-29 | 7 | 20d | 0d | start no earlier than 2008-08-25 |
| 9 | 1.8 | 4km Deep Refinement |  | 20d | 2008-09-01 | 2008-09-26 | 8 | 20d | 0d |  |
| 10 | 1.9 | 4km D-ESP (Flyer) |  | 5d | 2008-09-29 | 2008-10-03 | 9 | 20d | 0d | start no earlier than 2008-09-22 |
| 11 | 1.10 | Design MARS-ESP Concept |  | 15d | 2008-02-04 | 2008-02-22 |  | 140d | 0d | start no earlier than 2008-02-04 |
| 12 | 1.11 | MARS-ESP PDR | milestone | 0d | 2008-02-22 | 2008-02-22 | 11 | 140d | 0d |  |
| 13 | 1.12 | Detail Design MARS-ESP |  | 40d | 2008-02-25 | 2008-04-18 | 12 | 140d | 0d |  |
| 14 | 1.13 | MARS-ESP CDR | milestone | 0d | 2008-04-18 | 2008-04-18 | 13 | 140d | 120d |  |
| 15 | 1.14 | Develop MARS-ESP System |  | 20d | 2008-04-21 | 2008-05-16 | 14 | 120d | 100d |  |
| 16 | 1.15 | Configure/Test MARS-ESP |  | 20d | 2008-10-06 | 2008-10-31 | 10, 15 | 20d | 0d |  |
| 17 | 1.16 | MARS-ESP Readiness Review | milestone | 0d | 2008-10-31 | 2008-10-31 | 16 | 20d | 0d |  |
| 18 | 1.17 | Deploy MARS-ESP |  | 20d | 2008-11-03 | 2008-11-28 | 17 | 20d | 0d | start no earlier than 2008-10-27 |
| 19 | 1.18 | Configure Surface ESP-PCR |  | 20d | 2008-04-28 | 2008-05-23 |  | 133d | 16d | start no earlier than 2008-04-27 |
| 20 | 1.19 | ESP-PCR Surface deployment at M0 |  | 22d | 2008-06-17 | 2008-07-16 | 19 | 117d |  | start no earlier than 2008-06-17 |
| 22 | 2 | **MEGA (Moore)** |  | 190d | 2008-03-03 | 2008-11-21 |  | 25d |  |  |
| 23 | 2.1 | MFB Production |  | 40d | 2008-03-03 | 2008-04-25 |  | 55d | 0d | start no earlier than 2008-03-03 |
| 24 | 2.2 | MFB-ESP Core Integration |  | 40d | 2008-04-28 | 2008-06-20 | 23 | 55d | 0d |  |
| 25 | 2.3 | Integrate MFB/PCR with ESP Cores |  | 20d | 2008-06-23 | 2008-07-18 | 24 | 55d | 0d |  |
| 26 | 2.4 | Science validation of ESP-PCR (in lab) |  | 60d | 2008-07-21 | 2008-10-10 | 25 | 55d |  |  |
| 27 | 2.5 | Transfer MFB research |  | 15d | 2008-11-03 | 2008-11-21 |  | 25d |  | start no earlier than 2008-11-03 |

| ID | WBS | Task | Duration | Start | Finish | Predecessors | Total slack | Free slack | Constraint |
| --- | --- | --- | --- | --- | --- | --- | --- | --- | --- |
| 29 | 3 | **C-MORE** | 245d | 2008-01-21 | 2008-12-26 |  | 0d |  |  |
| 30 | 3.1 | Requirements Workshop | 10d | 2008-01-21 | 2008-02-01 |  | 235d |  | start no earlier than 2008-01-21 |
| 31 | 3.2 | Concept design of deployment | 40d | 2008-08-25 | 2008-10-17 |  | 50d |  | start no earlier than 2008-08-25 |
| 32 | 3.3 | Fabricate ESP Core (+MFB/PCR) | 40d | 2008-11-03 | 2008-12-26 |  | 0d |  | start no earlier than 2008-11-03 |
| 34 | 4 | **NSF** | 170d | 2008-01-07 | 2008-08-29 |  | 85d |  |  |
| 35 | 4.1 | MFB Production | 40d | 2008-01-07 | 2008-02-29 |  | 195d | 0d | start no earlier than 2008-01-07 |
| 36 | 4.2 | PCR Module Assembly | 20d | 2008-03-03 | 2008-03-28 | 35 | 195d |  | start no earlier than 2008-02-04 |
| 37 | 4.3 | Build/Test 2 Surface Moorings | 40d | 2008-07-07 | 2008-08-29 |  | 85d |  | start no earlier than 2008-07-07 |
| 39 | 5 | **NERACOOS (WHOI)** | 40d | 2008-11-03 | 2008-12-26 |  | 0d |  |  |
| 40 | 5.1 | ESP Core Production | 40d | 2008-11-03 | 2008-12-26 |  | 0d |  | start no earlier than 2008-11-03 |
| 42 | 6 | **MBARI** | 239d | 2008-01-01 | 2008-11-28 |  | 20d |  |  |
| 43 | 6.1 | ESP Core Refinements | 30d | 2008-01-01 | 2008-02-11 |  | 159d | 0d |  |
| 44 | 6.2 | Test Refinements/Ruby transition | 15d | 2008-02-12 | 2008-03-03 | 43 | 159d | 0d |  |
| 45 | 6.3 | GUI support for deployments | 55d | 2008-03-04 | 2008-05-19 | 44 | 159d |  | start no earlier than 2008-03-03 |
| 46 | 6.4 | **M0 Surface Deployments** | 88d | 2008-03-17 | 2008-07-16 |  | 117d |  |  |
| 47 | 6.4.1 | M0 dep 1 | 22d | 2008-03-17 | 2008-04-15 |  | 117d | 0d | start no earlier than 2008-03-17 |
| 48 | 6.4.2 | M0 dep 2 | 22d | 2008-04-16 | 2008-05-15 | 47 | 117d | 0d |  |
| 49 | 6.4.3 | M0 dep 3 | 22d | 2008-05-16 | 2008-06-16 | 48 | 117d | 0d |  |
| 50 | 6.4.4 | M0 dep 4, Networked | 22d | 2008-06-17 | 2008-07-16 | 49 | 117d |  |  |
| 51 | 6.5 | **Deep Deployments** | 70d | 2008-08-25 | 2008-11-28 |  | 20d |  |  |
| 52 | 6.5.1 | 4km D-ESP (Flyer) | 5d | 2008-08-25 | 2008-08-29 | 8SS | 85d |  | start no earlier than 2008-08-25 |
| 53 | 6.5.2 | 4km D-ESP (Flyer) | 5d | 2008-09-29 | 2008-10-03 | 10SS | 60d |  | start no earlier than 2008-09-22 |
| 54 | 6.5.3 | Deploy MARS-ESP | 20d | 2008-11-03 | 2008-11-28 | 18SS | 20d |  | start no earlier than 2008-10-27 |
