# 2008 Project Plan

Schedule from MS Project, 2008-01-01 to 2011-07-01.
MBARI

## Calendars

- Standard: Mon-Fri 08:00-12:00, 13:00-17:00; Sat-Sun off.

## Schedule

| ID | WBS | Task | Type | Duration | Start | Finish | Predecessors | Total slack | Free slack | Constraint |
| --- | --- | --- | --- | --- | --- | --- | --- | --- | --- | --- |
| 1 | 1 | **ASTEP** |  | 239d | 2008-01-01 | 2008-11-28 |  | 675d |  |  |
| 2 | 1.1 | Assemble and Test 4km Deep Sampler |  | 80d | 2008-01-01 | 2008-04-21 |  | 694d | 0d |  |
| 3 | 1.2 | Integrate 4k D-ESP |  | 20d | 2008-04-22 | 2008-05-19 | 2 | 694d | 0d |  |
| 4 | 1.3 | 4km (Pressurized Test) Readiness R | milestone | 0d | 2008-05-19 | 2008-05-19 | 3 | 694d | 0d |  |
| 5 | 1.4 | Simulated 4km Testing |  | 30d | 2008-05-20 | 2008-06-30 | 4 | 694d | 0d |  |
| 6 | 1.5 | Configure 4km D-ESP for profiling |  | 20d | 2008-07-01 | 2008-07-28 | 5 | 694d | 0d |  |
| 7 | 1.6 | 4km D-ESP (Deployment) Readiness review | milestone | 0d | 2008-07-28 | 2008-07-28 | 6 | 694d | 19d |  |
| 8 | 1.7 | 4km D-ESP (Flyer) |  | 5d | 2008-08-25 | 2008-08-29 | 7 | 675d | 0d | start no earlier than 2008-08-25 |
| 9 | 1.8 | 4km Deep Refinement |  | 20d | 2008-09-01 | 2008-09-26 | 8 | 675d | 0d |  |
| 10 | 1.9 | 4km D-ESP (Flyer) |  | 5d | 2008-09-29 | 2008-10-03 | 9 | 675d | 0d | start no earlier than 2008-09-22 |
| 11 | 1.10 | Design MARS-ESP Concept |  | 15d | 2008-02-04 | 2008-02-22 |  | 775d | 0d | start no earlier than 2008-02-04 |
| 12 | 1.11 | MARS-ESP PDR | milestone | 0d | 2008-02-22 | 2008-02-22 | 11 | 775d | 0d |  |
| 13 | 1.12 | Detail Design MARS-ESP |  | 40d | 2008-02-25 | 2008-04-18 | 12 | 775d | 0d |  |
| 14 | 1.13 | MARS-ESP CDR | milestone | 0d | 2008-04-18 | 2008-04-18 | 13 | 775d | 0d |  |
| 15 | 1.14 | Develop MARS-ESP System |  | 20d | 2008-04-21 | 2008-05-16 | 14 | 775d | 100d |  |
| 16 | 1.15 | Configure/Test MARS-ESP |  | 20d | 2008-10-06 | 2008-10-31 | 10, 15 | 675d | 0d |  |
| 17 | 1.16 | MARS-ESP Readiness Review | milestone | 0d | 2008-10-31 | 2008-10-31 | 16 | 675d | 0d |  |
| 18 | 1.17 | Deploy MARS-ESP |  | 20d | 2008-11-03 | 2008-11-28 | 17 | 675d | 0d | start no earlier than 2008-10-27 |
| 19 | 1.18 | Configure Surface ESP-PCR |  | 20d | 2008-04-28 | 2008-05-23 |  | 788d | 16d | start no earlier than 2008-04-27 |
| 20 | 1.19 | ESP-PCR Surface deployment at M0 |  | 22d | 2008-06-17 | 2008-07-16 | 19 | 772d |  | start no earlier than 2008-06-17 |
| 21 | 2 | **MEGA (Moore)** |  | 190d | 2008-03-03 | 2008-11-21 |  | 680d |  |  |
| 22 | 2.1 | MFB Production |  | 40d | 2008-03-03 | 2008-04-25 |  | 710d | 0d | start no earlier than 2008-03-03 |
| 23 | 2.2 | MFB-ESP Core Integration |  | 40d | 2008-04-28 | 2008-06-20 | 22 | 710d | 0d |  |
| 24 | 2.3 | Integrate MFB/PCR with ESP Cores |  | 20d | 2008-06-23 | 2008-07-18 | 23 | 710d | 0d |  |
| 25 | 2.4 | Science validation of ESP-PCR (in lab) |  | 60d | 2008-07-21 | 2008-10-10 | 24 | 710d |  |  |
| 26 | 2.5 | Transfer MFB research |  | 15d | 2008-11-03 | 2008-11-21 |  | 680d |  | start no earlier than 2008-11-03 |

| ID | WBS | Task | Duration | Start | Finish | Predecessors | Total slack | Free slack | Constraint |
| --- | --- | --- | --- | --- | --- | --- | --- | --- | --- |
| 27 | 3 | **C-MORE** | 245d | 2008-01-21 | 2008-12-26 |  | 655d |  |  |
| 28 | 3.1 | Requirements Workshop | 10d | 2008-01-21 | 2008-02-01 |  | 890d |  | start no earlier than 2008-01-21 |
| 29 | 3.2 | Concept design of deployment | 40d | 2008-08-25 | 2008-10-17 |  | 705d |  | start no earlier than 2008-08-25 |
| 30 | 3.3 | Fabricate ESP Core (+MFB/PCR) | 40d | 2008-11-03 | 2008-12-26 |  | 655d |  | start no earlier than 2008-11-03 |
| 31 | 4 | **NSF** | 170d | 2008-01-07 | 2008-08-29 |  | 740d |  |  |
| 32 | 4.1 | MFB Production | 40d | 2008-01-07 | 2008-02-29 |  | 850d | 0d | start no earlier than 2008-01-07 |
| 33 | 4.2 | PCR Module Assembly | 20d | 2008-03-03 | 2008-03-28 | 32 | 850d |  | start no earlier than 2008-02-04 |
| 34 | 4.3 | Build/Test 2 Surface Moorings | 40d | 2008-07-07 | 2008-08-29 |  | 740d |  | start no earlier than 2008-07-07 |
| 35 | 5 | **NERACOOS (WHOI)** | 40d | 2008-11-03 | 2008-12-26 |  | 655d |  |  |
| 36 | 5.1 | ESP Core Production | 40d | 2008-11-03 | 2008-12-26 |  | 655d |  | start no earlier than 2008-11-03 |
| 37 | 6 | **MBARI** | 239d | 2008-01-01 | 2008-11-28 |  | 675d |  |  |
| 38 | 6.1 | ESP Core Refinements | 30d | 2008-01-01 | 2008-02-11 |  | 814d | 0d |  |
| 39 | 6.2 | Test Refinements/Ruby transition | 15d | 2008-02-12 | 2008-03-03 | 38 | 814d | 0d |  |
| 40 | 6.3 | GUI support for deployments | 55d | 2008-03-04 | 2008-05-19 | 39 | 814d |  | start no earlier than 2008-03-03 |
| 41 | 6.4 | **M0 Surface Deployments** | 88d | 2008-03-17 | 2008-07-16 |  | 772d |  |  |
| 42 | 6.4.1 | M0 dep 1 | 22d | 2008-03-17 | 2008-04-15 |  | 772d | 0d | start no earlier than 2008-03-17 |
| 43 | 6.4.2 | M0 dep 2 | 22d | 2008-04-16 | 2008-05-15 | 42 | 772d | 0d |  |
| 44 | 6.4.3 | M0 dep 3 | 22d | 2008-05-16 | 2008-06-16 | 43 | 772d | 0d |  |
| 45 | 6.4.4 | M0 dep 4, Networked | 22d | 2008-06-17 | 2008-07-16 | 44 | 772d |  |  |
| 46 | 6.5 | **Deep Deployments** | 70d | 2008-08-25 | 2008-11-28 |  | 675d |  |  |
| 47 | 6.5.1 | 4km D-ESP (Flyer) | 5d | 2008-08-25 | 2008-08-29 | 8SS | 740d |  | start no earlier than 2008-08-25 |
| 48 | 6.5.2 | 4km D-ESP (Flyer) | 5d | 2008-09-29 | 2008-10-03 | 10SS | 715d |  | start no earlier than 2008-09-22 |
| 49 | 6.5.3 | Deploy MARS-ESP | 20d | 2008-11-03 | 2008-11-28 | 18SS | 675d |  | start no earlier than 2008-10-27 |
| 50 | 7 | **NOPP** | 914d? | 2008-01-01 | 2011-07-01 |  | 0d |  |  |
| 51 | 7.1 | **Build 2 Core ESPs** | 392d? | 2008-01-01 | 2009-07-01 |  | 522d |  |  |
| 52 | 7.1.1 | order COTS parts from current BOM | 1d? | 2008-01-01 | 2008-01-01 |  | 913d |  |  |
| 53 | 7.1.2 | electronic boards (order and populate) | 1d? | 2008-01-01 | 2008-01-01 |  | 913d |  |  |

| ID | WBS | Task | Duration | Start | Finish | Total slack | Constraint |
| --- | --- | --- | --- | --- | --- | --- | --- |
| 54 | 7.1.3 | **order machined parts** | 1d? | 2008-01-01 | 2008-01-01 | 913d |  |
| 55 | 7.1.3.1 | MBARI machining (order to acquire) | 1d? | 2008-01-01 | 2008-01-01 | 913d |  |
| 56 | 7.1.3.2 | External machining (order to acquire) | 1d? | 2008-01-01 | 2008-01-01 | 913d |  |
| 57 | 7.1.4 | **assemble 2 cores** | 1d? | 2008-01-01 | 2008-01-01 | 913d |  |
| 58 | 7.1.4.1 | electronic boards | 1d? | 2008-01-01 | 2008-01-01 | 913d |  |
| 59 | 7.1.4.2 | syringes/valves | 1d? | 2008-01-01 | 2008-01-01 | 913d |  |
| 60 | 7.1.4.3 | electric harnesses | 1d? | 2008-01-01 | 2008-01-01 | 913d |  |
| 61 | 7.1.4.4 | tubing | 1d? | 2008-01-01 | 2008-01-01 | 913d |  |
| 62 | 7.1.5 | **Ship to NOAA and WHOI** | 262d? | 2008-07-01 | 2009-07-01 | 522d |  |
| 63 | 7.1.5.1 | Train NOAA/WHOI workers | 262d? | 2008-07-01 | 2009-07-01 | 522d | finish no earlier than 2009-07-01 |
| 64 | 7.1.5.2 | Validate ESP function in partner labs | 262d? | 2008-07-01 | 2009-07-01 | 522d | start no earlier than 2008-07-01 |
| 65 | 7.1.6 | Fabricate 1 surface mooring | 262d? | 2008-07-01 | 2009-07-01 | 522d | start no earlier than 2008-07-01 |
| 66 | 7.1.7 | Initiate toxin assay development | 262d? | 2008-07-01 | 2009-07-01 | 522d | start no earlier than 2008-07-01 |
| 67 | 7.2 | **Validation studies at 2 sites** | 262d? | 2009-07-01 | 2010-07-01 | 261d |  |
| 68 | 7.2.1 | dockside application @ Salt Pond | 262d? | 2009-07-01 | 2010-07-01 | 261d | finish no earlier than 2010-07-01 |
| 69 | 7.2.2 | ground-truth IOOS ESP @ Buoy B | 262d? | 2009-07-01 | 2010-07-01 | 261d | start no earlier than 2009-07-01 |
| 70 | 7.2.3 | Analyze SHA/WC data from archived ESP data | 262d? | 2009-07-01 | 2010-07-01 | 261d | start no earlier than 2009-07-01 |
| 71 | 7.2.4 | build saxitoxin assay | 262d? | 2009-07-01 | 2010-07-01 | 261d | start no earlier than 2009-07-01 |
| 72 | 7.2.5 | assimilate data into models (IOOS supported) | 262d? | 2009-07-01 | 2010-07-01 | 261d | start no earlier than 2009-07-01 |
| 73 | 7.3 | **Network deployment (3 total)** | 262d? | 2010-07-01 | 2011-07-01 | 0d |  |
| 74 | 7.3.1 | 3 UNOLS cruises for deployment/turnaround/recovery | 262d? | 2010-07-01 | 2011-07-01 | 0d | finish no earlier than 2011-07-01 |
| 75 | 7.3.2 | Analyze SHA/WC data from archived ESP data | 262d? | 2010-07-01 | 2011-07-01 | 0d | start no earlier than 2010-07-01 |
| 76 | 7.3.3 | Deploy saxitoxin assay in 1 ESP unit | 262d? | 2010-07-01 | 2011-07-01 | 0d | start no earlier than 2010-07-01 |
| 77 | 7.3.4 | assimilate data into models (NOPP supported) | 262d? | 2010-07-01 | 2011-07-01 | 0d | start no earlier than 2010-07-01 |
