# 2008-2009 SURF Proposal Project Plan v2

Schedule from MS Project, 2008-01-01 to 2008-12-26.
MBARI

## Calendars

- Standard: Mon-Fri 08:00-12:00, 13:00-17:00; Sat-Sun off.

## Schedule

| ID | WBS | Task | Duration | Start | Finish | Predecessors | Total slack | Free slack | Constraint |
| --- | --- | --- | --- | --- | --- | --- | --- | --- | --- |
| 1 | 1 | **ASTEP** | 142d? | 2008-06-02 | 2008-12-16 |  | 8d |  |  |
| 2 | 1.1 | **Complete Neo Retrofit** | 44d? | 2008-06-02 | 2008-07-31 |  | 106d |  |  |
| 3 | 1.1.1 | Fix heater | 3d? | 2008-06-02 | 2008-06-04 |  | 106d | 0d | finish no earlier than 2008-06-04 |
| 4 | 1.1.2 | Calibrate at Room temperature | 2d? | 2008-06-05 | 2008-06-06 | 3 | 106d | 0d | finish no earlier than 2008-06-05 |
| 5 | 1.1.3 | Science forms lysate | 1d? | 2008-06-09 | 2008-06-09 | 4 | 106d | 0d |  |
| 6 | 1.1.4 | Perform full calibration | 4d? | 2008-06-10 | 2008-06-13 | 5 | 106d | 0d | start no earlier than 2008-06-09 |
| 7 | 1.1.5 | Science exercises Neo in Lab | 34d? | 2008-06-16 | 2008-07-31 | 6 | 106d |  | start no earlier than 2008-06-16 |
| 8 | 1.2 | **DWSM** | 140d? | 2008-06-04 | 2008-12-16 |  | 8d |  |  |
| 9 | 1.2.1 | Prepare for CDR | 4d? | 2008-06-04 | 2008-06-09 |  | 143d | 0d | finish no earlier than 2008-06-09 |
| 10 | 1.2.2 | CDR | 1d? | 2008-06-10 | 2008-06-10 | 9 | 143d |  | start no earlier than 2008-06-04 |
| 11 | 1.2.3 | Create final bell housing design | 5d | 2008-06-11 | 2008-06-17 | 10 | 8d |  |  |
| 12 | 1.2.4 | 'Swiss Cheese' plate design | 10d | 2008-06-18 | 2008-07-01 | 11 | 8d | 0d |  |
| 13 | 1.2.5 | manufacture housings/plates | 50d | 2008-07-02 | 2008-09-09 | 12 | 8d |  |  |
| 14 | 1.2.6 | Acquire fittings | 40d | 2008-07-02 | 2008-08-26 | 12 | 88d |  | start no earlier than 2008-06-11 |
| 15 | 1.2.7 | Acquire electronics | 30d | 2008-06-11 | 2008-07-22 | 10 | 113d |  | start no earlier than 2008-06-11 |
| 16 | 1.2.8 | Assemble DWSM | 30d | 2008-09-10 | 2008-10-21 | 13 | 8d |  |  |
| 17 | 1.2.9 | Software integration with dwarves | 20d | 2008-10-22 | 2008-11-18 | 16 | 8d |  |  |
| 18 | 1.2.10 | Tank Testing w/ surface core | 20d | 2008-11-19 | 2008-12-16 | 17 | 8d |  |  |
| 19 | 1.3 | **Sphere** | 1d? | 2008-06-05 | 2008-06-05 |  | 146d |  |  |
| 20 | 1.3.1 | **Machine Sphere** | 1d? | 2008-06-05 | 2008-06-05 |  | 146d |  |  |
| 21 | 1.3.1.1 | acquire sphere from Wah Chang | 1d? | 2008-06-05 | 2008-06-05 |  | 146d |  | start no earlier than 2008-06-05 |
| 22 | 1.3.1.2 | Send drawings and halves to Tapemation | 1d? | 2008-06-05 | 2008-06-05 |  | 146d |  | start no earlier than 2008-06-05 |
| 23 | 1.3.1.3 | Final machining review | 1d? | 2008-06-05 | 2008-06-05 |  | 146d |  | start no earlier than 2008-06-05 |
| 24 | 1.3.1.4 | Machine halves to drawings | 1d? | 2008-06-05 | 2008-06-05 |  | 146d |  | start no earlier than 2008-06-05 |

Notes:
- 1: ASTEP goes Dec 1 to Nov 31. Ends Nov 2008

| ID | WBS | Task | Duration | Start | Finish | Predecessors | Total slack | Free slack | Constraint |
| --- | --- | --- | --- | --- | --- | --- | --- | --- | --- |
| 25 | 1.3.2 | **Build Sphere** | 1d? | 2008-06-05 | 2008-06-05 |  | 146d |  |  |
| 26 | 1.3.2.1 | Order/acquire outside fittings/pass-throughs/o-rings | 1d? | 2008-06-05 | 2008-06-05 |  | 146d |  | start no earlier than 2008-06-05 |
| 27 | 1.3.2.2 | install hardware on sphere | 1d? | 2008-06-05 | 2008-06-05 |  | 146d |  | start no earlier than 2008-06-05 |
| 28 | 1.3.2.3 | He test sphere | 1d? | 2008-06-05 | 2008-06-05 |  | 146d |  | start no earlier than 2008-06-05 |
| 29 | 1.3.3 | **Pressure Test Sphere** | 1d? | 2008-06-05 | 2008-06-05 |  | 146d |  |  |
| 30 | 1.3.3.1 | Get on the Port Hueneme schedule | 1d? | 2008-06-05 | 2008-06-05 |  | 146d |  | start no earlier than 2008-06-05 |
| 31 | 1.3.3.2 | Send to Port Hueneme for pressure testing | 1d? | 2008-06-05 | 2008-06-05 |  | 146d |  | start no earlier than 2008-06-05 |
| 32 | 1.3.3.3 | Return sphere to MBARI | 1d? | 2008-06-05 | 2008-06-05 |  | 146d |  | start no earlier than 2008-06-05 |
| 33 | 1.4 | **Elevator** | 1d? | 2008-06-05 | 2008-06-05 |  | 146d |  |  |
| 34 | 1.4.1 | **Design** | 1d? | 2008-06-05 | 2008-06-05 |  | 146d |  |  |
| 35 | 1.4.1.1 | Elevator frame/battery frame | 1d? | 2008-06-05 | 2008-06-05 |  | 146d |  | start no earlier than 2008-06-05 |
| 36 | 1.4.1.2 | Landing structure | 1d? | 2008-06-05 | 2008-06-05 |  | 146d |  | start no earlier than 2008-06-05 |
| 37 | 1.4.1.3 | Floatation | 1d? | 2008-06-05 | 2008-06-05 |  | 146d |  | start no earlier than 2008-06-05 |
| 38 | 1.4.1.4 | Drop-weight | 1d? | 2008-06-05 | 2008-06-05 |  | 146d |  | start no earlier than 2008-06-05 |
| 39 | 1.4.1.5 | ROV wet-mate connector | 1d? | 2008-06-05 | 2008-06-05 |  | 146d |  | start no earlier than 2008-06-05 |
| 40 | 1.4.2 | **Acquire Parts** | 1d? | 2008-06-05 | 2008-06-05 |  | 146d |  |  |
| 41 | 1.4.2.1 | metal for frames | 1d? | 2008-06-05 | 2008-06-05 |  | 146d |  | start no earlier than 2008-06-05 |
| 42 | 1.4.2.2 | float packs | 1d? | 2008-06-05 | 2008-06-05 |  | 146d |  | start no earlier than 2008-06-05 |
| 43 | 1.4.2.3 | drop-weight | 1d? | 2008-06-05 | 2008-06-05 |  | 146d |  | start no earlier than 2008-06-05 |
| 44 | 1.4.2.4 | beacons/stobes | 1d? | 2008-06-05 | 2008-06-05 |  | 146d |  | start no earlier than 2008-06-05 |
| 45 | 1.4.3 | **Build elevator** | 1d? | 2008-06-05 | 2008-06-05 |  | 146d |  |  |
| 46 | 1.4.3.1 | Assemble acquired parts | 1d? | 2008-06-05 | 2008-06-05 |  | 146d |  | start no earlier than 2008-06-05 |
| 47 | 1.4.3.2 | Test | 1d? | 2008-06-05 | 2008-06-05 |  | 146d |  | start no earlier than 2008-06-05 |
| 48 | 2 | **MEGA (Moore)** | 190d | 2008-03-03 | 2008-11-21 |  | 25d |  |  |
| 49 | 2.1 | MFB Production | 40d | 2008-03-03 | 2008-04-25 |  | 55d | 0d | start no earlier than 2008-03-03 |
| 50 | 2.2 | MFB-ESP Core Integration | 40d | 2008-04-28 | 2008-06-20 | 49 | 55d | 0d |  |
| 51 | 2.3 | Integrate MFB/PCR with ESP Cores | 20d | 2008-06-23 | 2008-07-18 | 50 | 55d | 0d |  |
| 52 | 2.4 | Science validation of ESP-PCR (in lab) | 60d | 2008-07-21 | 2008-10-10 | 51 | 55d |  |  |
| 53 | 2.5 | Transfer MFB research | 15d | 2008-11-03 | 2008-11-21 |  | 25d |  | start no earlier than 2008-11-03 |

| ID | WBS | Task | Duration | Start | Finish | Predecessors | Total slack | Free slack | Constraint |
| --- | --- | --- | --- | --- | --- | --- | --- | --- | --- |
| 54 | 3 | **C-MORE** | 245d | 2008-01-21 | 2008-12-26 |  | 0d |  |  |
| 55 | 3.1 | Requirements Workshop | 10d | 2008-01-21 | 2008-02-01 |  | 235d |  | start no earlier than 2008-01-21 |
| 56 | 3.2 | Concept design of deployment | 40d | 2008-08-25 | 2008-10-17 |  | 50d |  | start no earlier than 2008-08-25 |
| 57 | 3.3 | Fabricate ESP Core (+MFB/PCR) | 40d | 2008-11-03 | 2008-12-26 |  | 0d |  | start no earlier than 2008-11-03 |
| 58 | 4 | **NSF** | 170d | 2008-01-07 | 2008-08-29 |  | 85d |  |  |
| 59 | 4.1 | MFB Production | 40d | 2008-01-07 | 2008-02-29 |  | 195d | 0d | start no earlier than 2008-01-07 |
| 60 | 4.2 | PCR Module Assembly | 20d | 2008-03-03 | 2008-03-28 | 59 | 195d |  | start no earlier than 2008-02-04 |
| 61 | 4.3 | Build/Test 2 Surface Moorings | 40d | 2008-07-07 | 2008-08-29 |  | 85d |  | start no earlier than 2008-07-07 |
| 62 | 5 | **MBARI** | 234d | 2008-01-01 | 2008-11-21 |  | 25d |  |  |
| 63 | 5.1 | ESP Core Refinements | 30d | 2008-01-01 | 2008-02-11 |  | 159d | 0d |  |
| 64 | 5.2 | Test Refinements/Ruby transition | 15d | 2008-02-12 | 2008-03-03 | 63 | 159d | 0d |  |
| 65 | 5.3 | GUI support for deployments | 55d | 2008-03-04 | 2008-05-19 | 64 | 159d |  | start no earlier than 2008-03-03 |
| 66 | 5.4 | **M0 Surface Deployments** | 88d | 2008-03-17 | 2008-07-16 |  | 117d |  |  |
| 67 | 5.4.1 | M0 dep 1 | 22d | 2008-03-17 | 2008-04-15 |  | 117d | 0d | start no earlier than 2008-03-17 |
| 68 | 5.4.2 | M0 dep 2 | 22d | 2008-04-16 | 2008-05-15 | 67 | 117d | 0d |  |
| 69 | 5.4.3 | M0 dep 3 | 22d | 2008-05-16 | 2008-06-16 | 68 | 117d | 0d |  |
| 70 | 5.4.4 | M0 dep 4, Networked | 22d | 2008-06-17 | 2008-07-16 | 69 | 117d |  |  |
| 71 | 5.5 | **Deep Deployments** | 65d | 2008-08-25 | 2008-11-21 |  | 25d |  |  |
| 72 | 5.5.1 | 4km D-ESP (Flyer) | 5d | 2008-08-25 | 2008-08-29 |  | 85d |  | start no earlier than 2008-08-25 |
| 73 | 5.5.2 | 4km D-ESP (Flyer) | 5d | 2008-09-22 | 2008-09-26 |  | 65d |  | start no earlier than 2008-09-22 |
| 74 | 5.5.3 | Deploy MARS-ESP | 20d | 2008-10-27 | 2008-11-21 |  | 25d |  | start no earlier than 2008-10-27 |
