# 2008-2009 SURF Proposal Project Plan

Schedule from MS Project, 2008-01-01 to 2008-12-26.
MBARI

## Calendars

- Standard: Mon-Fri 08:00-12:00, 13:00-17:00; Sat-Sun off.

## Schedule

| ID | WBS | Task | Type | Duration | Start | Finish | Predecessors | Total slack | Free slack | Constraint |
| --- | --- | --- | --- | --- | --- | --- | --- | --- | --- | --- |
| 1 | 1 | **ASTEP** |  | 239d | 2008-01-01 | 2008-11-28 |  | 20d |  |  |
| 2 | 1.1 | Assemble and Test 4km Deep Sampler |  | 80d | 2008-01-01 | 2008-04-21 |  | 694d | 0d |  |
| 3 | 1.2 | Integrate 4k D-ESP |  | 20d | 2008-04-22 | 2008-05-19 | 2 | 694d | 0d |  |
| 4 | 1.3 | 4km (Pressurized Test) Readiness R | milestone | 0d | 2008-05-19 | 2008-05-19 | 3 | 694d | 0d |  |
| 5 | 1.4 | Simulated 4km Testing |  | 30d | 2008-05-20 | 2008-06-30 | 4 | 694d | 0d |  |
| 6 | 1.5 | Configure 4km D-ESP for profiling |  | 20d | 2008-07-01 | 2008-07-28 | 5 | 694d | 0d |  |
| 7 | 1.6 | 4km D-ESP (Deployment) Readiness review | milestone | 0d | 2008-07-28 | 2008-07-28 | 6 | 694d | 19d |  |
| 8 | 1.7 | 4km D-ESP (Flyer) |  | 5d | 2008-08-25 | 2008-08-29 | 7 | 675d | 0d | start no earlier than 2008-08-25 |
| 9 | 1.8 | 4km Deep Refinement |  | 20d | 2008-09-01 | 2008-09-26 | 8 | 675d | 0d |  |
| 10 | 1.9 | 4km D-ESP (Flyer) |  | 5d | 2008-09-29 | 2008-10-03 | 9 | 675d | 0d | start no earlier than 2008-09-22 |
| 11 | 1.10 | Design MARS-ESP Concept |  | 15d | 2008-02-04 | 2008-02-22 |  | 775d | 0d | start no earlier than 2008-02-04 |
| 12 | 1.11 | MARS-ESP PDR | milestone | 0d | 2008-02-22 | 2008-02-22 | 11 | 775d | 0d |  |
| 13 | 1.12 | Detail Design MARS-ESP |  | 40d | 2008-02-25 | 2008-04-18 | 12 | 775d | 0d |  |
| 14 | 1.13 | MARS-ESP CDR | milestone | 0d | 2008-04-18 | 2008-04-18 | 13 | 775d | 0d |  |
| 15 | 1.14 | Develop MARS-ESP System |  | 20d | 2008-04-21 | 2008-05-16 | 14 | 775d | 100d |  |
| 16 | 1.15 | Configure/Test MARS-ESP |  | 20d | 2008-10-06 | 2008-10-31 | 10, 15 | 675d | 0d |  |
| 17 | 1.16 | MARS-ESP Readiness Review | milestone | 0d | 2008-10-31 | 2008-10-31 | 16 | 675d | 0d |  |
| 18 | 1.17 | Deploy MARS-ESP |  | 20d | 2008-11-03 | 2008-11-28 | 17 | 675d | 0d | start no earlier than 2008-10-27 |
| 19 | 1.18 | Configure Surface ESP-PCR |  | 20d | 2008-04-28 | 2008-05-23 |  | 788d | 16d | start no earlier than 2008-04-27 |
| 20 | 1.19 | ESP-PCR Surface deployment at M0 |  | 22d | 2008-06-17 | 2008-07-16 | 19 | 772d |  | start no earlier than 2008-06-17 |
| 21 | 2 | **MEGA (Moore)** |  | 190d | 2008-03-03 | 2008-11-21 |  | 25d |  |  |
| 22 | 2.1 | MFB Production |  | 40d | 2008-03-03 | 2008-04-25 |  | 710d | 0d | start no earlier than 2008-03-03 |
| 23 | 2.2 | MFB-ESP Core Integration |  | 40d | 2008-04-28 | 2008-06-20 | 22 | 710d | 0d |  |
| 24 | 2.3 | Integrate MFB/PCR with ESP Cores |  | 20d | 2008-06-23 | 2008-07-18 | 23 | 710d | 0d |  |
| 25 | 2.4 | Science validation of ESP-PCR (in lab) |  | 60d | 2008-07-21 | 2008-10-10 | 24 | 710d |  |  |
| 26 | 2.5 | Transfer MFB research |  | 15d | 2008-11-03 | 2008-11-21 |  | 680d |  | start no earlier than 2008-11-03 |

Notes:
- 1: ASTEP goes Dec 1 to Nov 31. Ends Nov 2008

| ID | WBS | Task | Duration | Start | Finish | Predecessors | Total slack | Free slack | Constraint |
| --- | --- | --- | --- | --- | --- | --- | --- | --- | --- |
| 27 | 3 | **C-MORE** | 245d | 2008-01-21 | 2008-12-26 |  | 0d |  |  |
| 28 | 3.1 | Requirements Workshop | 10d | 2008-01-21 | 2008-02-01 |  | 890d |  | start no earlier than 2008-01-21 |
| 29 | 3.2 | Concept design of deployment | 40d | 2008-08-25 | 2008-10-17 |  | 705d |  | start no earlier than 2008-08-25 |
| 30 | 3.3 | Fabricate ESP Core (+MFB/PCR) | 40d | 2008-11-03 | 2008-12-26 |  | 0d |  | start no earlier than 2008-11-03 |
| 31 | 4 | **NSF** | 170d | 2008-01-07 | 2008-08-29 |  | 85d |  |  |
| 32 | 4.1 | MFB Production | 40d | 2008-01-07 | 2008-02-29 |  | 850d | 0d | start no earlier than 2008-01-07 |
| 33 | 4.2 | PCR Module Assembly | 20d | 2008-03-03 | 2008-03-28 | 32 | 850d |  | start no earlier than 2008-02-04 |
| 34 | 4.3 | Build/Test 2 Surface Moorings | 40d | 2008-07-07 | 2008-08-29 |  | 740d |  | start no earlier than 2008-07-07 |
| 35 | 5 | **MBARI** | 239d | 2008-01-01 | 2008-11-28 |  | 20d |  |  |
| 36 | 5.1 | ESP Core Refinements | 30d | 2008-01-01 | 2008-02-11 |  | 814d | 0d |  |
| 37 | 5.2 | Test Refinements/Ruby transition | 15d | 2008-02-12 | 2008-03-03 | 36 | 814d | 0d |  |
| 38 | 5.3 | GUI support for deployments | 55d | 2008-03-04 | 2008-05-19 | 37 | 814d |  | start no earlier than 2008-03-03 |
| 39 | 5.4 | **M0 Surface Deployments** | 88d | 2008-03-17 | 2008-07-16 |  | 117d |  |  |
| 40 | 5.4.1 | M0 dep 1 | 22d | 2008-03-17 | 2008-04-15 |  | 117d | 0d | start no earlier than 2008-03-17 |
| 41 | 5.4.2 | M0 dep 2 | 22d | 2008-04-16 | 2008-05-15 | 40 | 117d | 0d |  |
| 42 | 5.4.3 | M0 dep 3 | 22d | 2008-05-16 | 2008-06-16 | 41 | 117d | 0d |  |
| 43 | 5.4.4 | M0 dep 4, Networked | 22d | 2008-06-17 | 2008-07-16 | 42 | 117d |  |  |
| 44 | 5.5 | **Deep Deployments** | 70d | 2008-08-25 | 2008-11-28 |  | 20d |  |  |
| 45 | 5.5.1 | 4km D-ESP (Flyer) | 5d | 2008-08-25 | 2008-08-29 | 8SS | 85d |  | start no earlier than 2008-08-25 |
| 46 | 5.5.2 | 4km D-ESP (Flyer) | 5d | 2008-09-29 | 2008-10-03 | 10SS | 60d |  | start no earlier than 2008-09-22 |
| 47 | 5.5.3 | Deploy MARS-ESP | 20d | 2008-11-03 | 2008-11-28 | 18SS | 20d |  | start no earlier than 2008-10-27 |
